# habitat2

Schedule from MS Project, 2008-08-27 to 2009-03-31, A marks actual dates.
WL / Delft Hydraulics

## Calendars

- Standard: Mon-Fri 08:00-12:00, 13:00-17:00; Sat-Sun off.

## Resources

| Resource |
| --- |
| Erik |
| Onno |
| Gena |
| Paul |
| Fedor |
| Arnout |
| Alex |

## Schedule

| ID | WBS | Task | Duration | Start | Finish | Complete | Remaining | Total slack | Constraint | Resources | Work | Actual work | Text1 |
| --- | --- | --- | --- | --- | --- | --- | --- | --- | --- | --- | --- | --- | --- |
| 1 | 1 | **Map control decorations** | 137d | 2008-08-27 A | 2009-03-05 | 71% | 39.67d | 18d |  |  | 120h | 81.45h |  |
| 2 | 1.1 | North / south arrow | 0.91d | 2008-08-27 A | 2008-08-27 A | 100% |  |  | start no earlier than 2008-08-27 | Gena [10%]; Arnout | 8h | 8h | 100 |
| 3 | 1.2 | Cross-sectional profiles | 5.64d | 2008-08-28 A | 2009-02-13 | 50% | 2.82d | 32.36d | start no earlier than 2008-08-28 | Alex | 32h | 9.45h | 100 |
| 4 | 1.3 | Scale | 3d | 2008-09-02 A | 2008-09-05 A | 100% |  |  | start no earlier than 2008-09-02 | Arnout | 24h | 24h | 100 |
| 5 | 1.4 | Classificatie aanpassen (gui dialog) | 10d | 2009-02-09 A | 2009-02-20 A | 100% |  |  | start no earlier than 2009-02-09 | Erik [50%] | 40h | 40h |  |
| 6 | 1.5 | Opslaan en ophalen van classificatie gegevens | 4d | 2009-03-02 | 2009-03-05 |  |  | 18d | start no earlier than 2009-03-02 | Gena [50%] | 16h |  | 20 |
| 7 | 2 | **Conversie applicatie voor kaartlagen (?)** | 13d | 2009-03-02 | 2009-03-18 |  |  | 9d |  |  | 72h |  |  |
| 8 | 2.1 | Uitzoeken wat werkt en niet werkt voor Resample | 2d | 2009-03-02 | 2009-03-03 |  |  | 20d | start no earlier than 2009-03-02 | Erik | 16h |  |  |
| 9 | 2.2 | Dummy proef maken | 3d | 2009-03-02 | 2009-03-04 |  |  | 19d | start no earlier than 2009-03-02 | Erik | 24h |  |  |
| 10 | 2.3 | Bug fixes + overig | 8d | 2009-03-09 | 2009-03-18 |  |  | 9d | start no earlier than 2009-03-09 | Erik [50%] | 32h |  |  |
| 11 | 3 | **DelftShell upgrade** | 20.77d | 2009-02-02 A | 2009-03-02 | 27% | 15.13d | 21.23d |  |  | 168h | 55.07h |  |
| 12 | 3.1 | Huidig opslagmechanisme doorvoeren voor Habitat | 9.33d | 2009-02-02 A | 2009-02-13 | 30% | 6.53d | 32.67d | start no earlier than 2009-02-02 | Onno [50%]; Gena [50%] | 56h | 22.4h |  |
| 13 | 3.2 | Importeren oude projecten (XML > DB) | 11.67d | 2009-02-09 A | 2009-02-24 | 50% | 5.83d | 25.33d | start no earlier than 2009-02-09 | Gena [50%]; Onno [50%] | 56h | 32.67h |  |
| 14 | 3.3 | Toolbox migreren naar nieuwe versie | 10.77d | 2009-02-16 | 2009-03-02 |  |  | 21.23d | start no earlier than 2009-02-16 | Onno [50%]; Gena [15%] | 56h |  | 50 |
| 15 | 4 | **Nieuwe functionaliteit PcRaster implementeren in Habitat** | 113.38d | 2008-10-01 A | 2009-03-09 | 48% | 59.39d | 16.62d |  |  | 264h | 116.69h |  |
| 16 | 4.1 | Implement new GridTimeSeries data type | 10d | 2008-10-01 A | 2009-03-09 | 46% | 5.38d | 16.62d | start no earlier than 2008-10-01 | Gena; Fedor [25%] | 80h | 27.69h | 100 |
| 17 | 4.2 | Opzetten van klassen die rasterlagen laden (GDAL/NetCDF) | 7.62d | 2008-10-27 A | 2008-11-05 A | 100% |  |  | start no earlier than 2008-10-25 | Gena [50%]; Fedor [25%]; Arnout [50%] | 40h | 40h | 100 |
| 18 | 4.3 | Tussenresultaten facultatief opslaan | 5d | 2009-02-09 | 2009-02-13 |  |  | 32d | start no earlier than 2009-02-09 | Onno [50%]; Gena [10%] | 24h |  |  |
| 19 | 4.4 | Upgrade Habitat PCRaster wrapper to a time-series grids | 17.5d | 2008-12-01 A | 2009-03-05 | 50% | 8.75d | 18.25d | start no earlier than 2008-11-30 | Erik [50%]; Onno [20%]; Gena [10%] | 80h | 45h |  |
| 20 | 4.5 | Upgrade all Habitat forms to a new GridTimeSeries data type | 5d | 2009-01-26 A | 2009-02-20 | 10% | 4.5d | 27.5d | start no earlier than 2009-01-26 | Erik | 40h | 4h |  |
| 21 | 5 | **GUI controls development / upgrade** | 57d | 2009-01-12 A | 2009-03-31 | 44% | 31.67d | 0d |  |  | 64h | 32h |  |
| 22 | 5.1 | Grid time series navigation (time) control | 3.2d | 2009-01-12 A | 2009-01-15 A | 100% |  |  | start no earlier than 2009-01-12 | Gena [25%]; Erik | 32h | 32h | 100 |
| 23 | 5.2 | Chart control, upgrade from Nplot to TeeChart | 2d | 2009-03-30 | 2009-03-31 |  |  | 0d | start no earlier than 2009-03-30 | Alex | 16h |  | 100 |
| 24 | 5.3 | Table control - use XtraGrid instead of standard DataGridView | 2d | 2009-03-30 | 2009-03-31 |  |  | 0d | start no earlier than 2009-03-30 | Alex | 16h |  | 100 |

Notes:
- 24: Overlapping
